# Lab Build Project - Sample

How a schedule from MS Project changed from version to version. A marks actual dates.

## Version 1 (saved 2009-09-02, file 2 - Resource - Lab Build.mpp)

| ID | WBS | Task | Duration | Start | Finish | Total float |
| --- | --- | --- | --- | --- | --- | --- |
| 1 |  | Project approved | 0d | 2009-01-05 | 2009-01-05 | 1d |
| 2 | 2 | **Project Management** | 1d | 2009-01-05 | 2009-01-05 | 0d |
| 3 |  | Plan project | 1d | 2009-01-05 | 2009-01-05 | 0d |
| 4 |  | Monitor & control project | 1d | 2009-01-05 | 2009-01-05 | 0d |
| 5 |  | Close project | 1d | 2009-01-05 | 2009-01-05 | 0d |
| 6 | 3 | **Design** | 1d | 2009-01-05 | 2009-01-05 | 0d |
| 7 |  | Analyse lab requirements | 1d | 2009-01-05 | 2009-01-05 | 0d |
| 8 |  | Develop furniture specs | 1d | 2009-01-05 | 2009-01-05 | 0d |
| 9 |  | Develop equipment specs | 1d | 2009-01-05 | 2009-01-05 | 0d |
| 10 | 3.4 | **Design lab interiors** | 1d | 2009-01-05 | 2009-01-05 | 0d |
| 11 |  | Design lab interiors - Borlaug | 1d | 2009-01-05 | 2009-01-05 | 0d |
| 12 |  | Design lab interiors - Marquez | 1d | 2009-01-05 | 2009-01-05 | 0d |
| 13 |  | Design lab interiors - Salam | 1d | 2009-01-05 | 2009-01-05 | 0d |
| 14 |  | Design lab interiors - Sen | 1d | 2009-01-05 | 2009-01-05 | 0d |
| 15 | 3.5 | **Develop construction documents** | 1d | 2009-01-05 | 2009-01-05 | 0d |
| 16 |  | Develop architectural specs | 1d | 2009-01-05 | 2009-01-05 | 0d |
| 17 |  | Develop structural specs | 1d | 2009-01-05 | 2009-01-05 | 0d |
| 18 |  | Develop electrical specs | 1d | 2009-01-05 | 2009-01-05 | 0d |
| 19 |  | Develop mechanical specs | 1d | 2009-01-05 | 2009-01-05 | 0d |
| 20 |  | Develop communications/data specs | 1d | 2009-01-05 | 2009-01-05 | 0d |
| 21 |  | Develop security specs | 1d | 2009-01-05 | 2009-01-05 | 0d |
| 22 | 4 | **Construction** | 1d | 2009-01-05 | 2009-01-05 | 0d |
| 23 | 4.1 | **Borlaug Building** | 1d | 2009-01-05 | 2009-01-05 | 0d |
| 24 |  | Build Lab B107 | 1d | 2009-01-05 | 2009-01-05 | 0d |
| 25 |  | Build Lab B108 | 1d | 2009-01-05 | 2009-01-05 | 0d |
| 26 | 4.2 | **Marquez Library** | 1d | 2009-01-05 | 2009-01-05 | 0d |
| 27 |  | Build Lab L315 | 1d | 2009-01-05 | 2009-01-05 | 0d |
| 28 |  | Build Lab L316 | 1d | 2009-01-05 | 2009-01-05 | 0d |
| 29 | 4.3 | **Salam Center** | 1d | 2009-01-05 | 2009-01-05 | 0d |
| 30 |  | Build Lab S324 | 1d | 2009-01-05 | 2009-01-05 | 0d |
| 31 |  | Build Lab S325 | 1d | 2009-01-05 | 2009-01-05 | 0d |
| 32 |  | Build Lab S326 | 1d | 2009-01-05 | 2009-01-05 | 0d |
| 33 | 4.4 | **Sen Building** | 1d | 2009-01-05 | 2009-01-05 | 0d |
| 34 |  | Build Lab E210 | 1d | 2009-01-05 | 2009-01-05 | 0d |
| 35 |  | Build Lab E211 | 1d | 2009-01-05 | 2009-01-05 | 0d |
| 36 |  | Build Lab E212 | 1d | 2009-01-05 | 2009-01-05 | 0d |
| 37 | 5 | **Commissioning** | 1d | 2009-01-05 | 2009-01-05 | 0d |
| 38 |  | Test all labs | 1d | 2009-01-05 | 2009-01-05 | 0d |
| 39 |  | Produce as-built documents for all labs | 1d | 2009-01-05 | 2009-01-05 | 0d |
| 40 |  | Produce operations and maintenance manuals | 1d | 2009-01-05 | 2009-01-05 | 0d |
| 41 |  | Project complete | 0d | 2009-01-05 | 2009-01-05 | 1d |

## Version 2 (saved 2009-09-02, file 5 - Schedule - Lab Build.mpp)

Last finish 2009-01-05 → 2009-08-28 (+235d).

Added:

| ID | Task | Duration | Start | Finish | Predecessors |
| --- | --- | --- | --- | --- | --- |
| 6 | Project plan approved | 0d | 2009-02-27 | 2009-02-27 | 3 |
| 23 | Lab requirements complete | 0d | 2009-03-13 | 2009-03-13 | 8 |
| 24 | Construction documents complete | 0d | 2009-04-20 | 2009-04-20 | 17, 18, 19, 20, 21, 22 |
| 25 | Designs complete | 0d | 2009-05-04 | 2009-05-04 | 9, 10, 16, 13, 14, 15, 17, 18, 19, 20, 21, 22 |
| 41 | Lab construction started | 0d | 2009-07-06 | 2009-07-06 |  |
| 46 | Operations manuals complete | 0d | 2009-05-19 | 2009-05-19 | 45 |
| 47 | Labs complete | 0d | 2009-08-07 | 2009-08-07 | 43 |

Changed:

| ID | Task | Start | Finish | Duration | Total float | Predecessors | Other |
| --- | --- | --- | --- | --- | --- | --- | --- |
| 2 | **Project Management** |  | 2009-01-05 → 2009-08-28 (+235d) | 1d → 166d |  |  |  |
| 3 | Plan project |  | 2009-01-05 → 2009-02-27 (+53d) | 1d → 40d |  | none → 1 | resources none → Project Manager [37.5%]; Procurement Manager [12.5%]; Facilities Manager [12.5%]; Information Systems Director [12.5%]; Architect; General Contractor; Mechanical Consultant; Electrical Consultant; Communications Consultant; Security Consultant; Interior Designer |
| 4 | Monitor & control project | 2009-01-05 → 2009-03-02 (+56d) | 2009-01-05 → 2009-08-21 (+228d) | 1d → 121d |  | none → 3 | resources none → Project Manager [19.8%]; Procurement Manager [5%]; Information Systems Director [5%]; Facilities Manager [5%] |
| 5 | Close project | 2009-01-05 → 2009-08-24 (+231d) | 2009-01-05 → 2009-08-28 (+235d) | 1d → 5d |  | none → 4, 43, 44, 45 | resources none → Project Manager; Information Systems Director; Facilities Manager; Procurement Manager; Architect; General Contractor; Interior Designer |
| 7 | **Design** | 2009-01-05 → 2009-03-02 (+56d) | 2009-01-05 → 2009-05-04 (+119d) | 1d → 45d | 0d → 42d |  |  |
| 8 | Analyse lab requirements | 2009-01-05 → 2009-03-02 (+56d) | 2009-01-05 → 2009-03-13 (+67d) | 1d → 10d | 0d → 42d | none → 3 | resources none → Information Systems Director [20%]; Facilities Manager [20%]; Procurement Manager [20%]; Interior Designer [20%]; Architect [20%]; Mechanical Consultant [20%]; Electrical Consultant [20%]; Security Consultant [20%]; Communications Consultant [20%] |
| 9 | Develop furniture specs | 2009-01-05 → 2009-03-16 (+70d) | 2009-01-05 → 2009-04-03 (+88d) | 1d → 15d | 0d → 42d | none → 8 | resources none → Facilities Manager [6.7%]; Interior Designer [33.3%] |
| 10 | Develop equipment specs | 2009-01-05 → 2009-03-16 (+70d) | 2009-01-05 → 2009-04-03 (+88d) | 1d → 15d | 0d → 52d | none → 8 | resources none → Information Systems Director [26.7%] |
| 11 | **Design lab interiors** | 2009-01-05 → 2009-04-06 (+91d) | 2009-01-05 → 2009-05-04 (+119d) | 1d → 20d | 0d → 42d |  |  |
| 12 | Design lab interiors - Borlaug | 2009-01-05 → 2009-04-06 (+91d) | 2009-01-05 → 2009-05-04 (+119d) | 1d → 20d | 0d → 52d | none → 9 | resources none → Interior Designer [20%] |
| 13 | Design lab interiors - Marquez | 2009-01-05 → 2009-04-06 (+91d) | 2009-01-05 → 2009-05-04 (+119d) | 1d → 20d | 0d → 50d | none → 9 | resources none → Interior Designer [20%] |
| 14 | Design lab interiors - Salam | 2009-01-05 → 2009-04-06 (+91d) | 2009-01-05 → 2009-05-04 (+119d) | 1d → 20d | 0d → 42d | none → 9 | resources none → Interior Designer [25%] |
| 15 | Design lab interiors - Sen | 2009-01-05 → 2009-04-06 (+91d) | 2009-01-05 → 2009-05-04 (+119d) | 1d → 20d | 0d → 43d | none → 9 | resources none → Interior Designer [25%] |
| 16 | **Develop construction documents** | 2009-01-05 → 2009-03-16 (+70d) | 2009-01-05 → 2009-04-20 (+105d) | 1d → 25d | 0d → 52d |  |  |
| 17 | Develop architectural specs | 2009-01-05 → 2009-03-16 (+70d) | 2009-01-05 → 2009-03-27 (+81d) | 1d → 10d | 0d → 67d | none → 8 | resources none → Architect |
| 18 | Develop structural specs | 2009-01-05 → 2009-03-30 (+84d) | 2009-01-05 → 2009-04-13 (+98d) | 1d → 10d | 0d → 57d | none → 8 | resources none → Architect |
| 19 | Develop electrical specs | 2009-01-05 → 2009-04-06 (+91d) | 2009-01-05 → 2009-04-20 (+105d) | 1d → 10d | 0d → 52d | none → 10 | resources none → Electrical Consultant |
| 20 | Develop mechanical specs | 2009-01-05 → 2009-04-06 (+91d) | 2009-01-05 → 2009-04-20 (+105d) | 1d → 10d | 0d → 52d | none → 10 | resources none → Mechanical Consultant |
| 21 | Develop communications/data specs | 2009-01-05 → 2009-04-06 (+91d) | 2009-01-05 → 2009-04-20 (+105d) | 1d → 10d | 0d → 52d | none → 10 | resources none → Communications Consultant |
| 22 | Develop security specs | 2009-01-05 → 2009-03-16 (+70d) | 2009-01-05 → 2009-03-20 (+74d) | 1d → 5d | 0d → 72d | none → 8 | resources none → Security Consultant |
| 26 | **Construction** | 2009-01-05 → 2009-07-06 (+182d) | 2009-01-05 → 2009-08-04 (+211d) | 1d → 21d | 0d → 13d |  | constraint none → start no earlier than 2009-07-06 |
| 27 | **Borlaug Building** | 2009-01-05 → 2009-07-06 (+182d) | 2009-01-05 → 2009-07-22 (+198d) | 1d → 13d | 0d → 8d |  |  |
| 28 | Build Lab B107 | 2009-01-05 → 2009-07-16 (+192d) | 2009-01-05 → 2009-07-22 (+198d) | 1d → 5d | 0d → 8d | none → 12, 17, 18, 19, 20, 21, 23 | resources none → General Contractor [200%]; Chairs [21 chairs]; Student workstations [20 desks]; Instructor workstations [1 desks]; Whiteboards [4 boards]; Screens [2 units]; Tables [2 tables]; Projectors [2 units]; PC systems [21 PCs]; Displays [21 monitors]; Scanners [1 scanners]; Printers [1 printers] |
| 29 | Build Lab B108 | 2009-01-05 → 2009-07-06 (+182d) | 2009-01-05 → 2009-07-15 (+191d) | 1d → 8d | 0d → 13d | none → 12, 17, 18, 19, 20, 21, 22 | resources none → Chairs [31 chairs]; Displays [31 monitors]; General Contractor [200%]; Instructor workstations [1 desks]; PC systems [31 PCs]; Projectors [2 units]; Scanners [1 scanners]; Screens [2 units]; Tables [2 tables]; Whiteboards [4 boards]; Student workstations [30 desks]; Printers [1 printers] |
| 30 | **Marquez Library** | 2009-01-05 → 2009-07-06 (+182d) | 2009-01-05 → 2009-07-22 (+198d) | 1d → 13d | 0d → 8d |  |  |
| 31 | Build Lab L315 | 2009-01-05 → 2009-07-14 (+190d) | 2009-01-05 → 2009-07-22 (+198d) | 1d → 7d | 0d → 8d | none → 17, 18, 19, 20, 21, 22, 13 | resources none → Chairs [31 chairs]; Displays [31 monitors]; General Contractor [200%]; Instructor workstations [1 desks]; PC systems [31 PCs]; Projectors [2 units]; Scanners [1 scanners]; Screens [2 units]; Tables [2 tables]; Whiteboards [4 boards]; Student workstations [30 desks]; Printers [1 printers] |
| 32 | Build Lab L316 | 2009-01-05 → 2009-07-06 (+182d) | 2009-01-05 → 2009-07-13 (+189d) | 1d → 6d | 0d → 15d | none → 17, 18, 19, 20, 21, 22, 13 | resources none → Chairs [21 chairs]; General Contractor [200%]; Instructor workstations [1 desks]; Mac systems [21 Macs]; Projectors [2 units]; Scanners [1 scanners]; Screens [2 units]; Tables [2 tables]; Whiteboards [4 boards]; Student workstations [20 desks]; Printers [1 printers] |
| 33 | **Salam Center** | 2009-01-05 → 2009-07-06 (+182d) | 2009-01-05 → 2009-08-04 (+211d) | 1d → 21d |  |  |  |
| 34 | Build Lab S324 | 2009-01-05 → 2009-07-28 (+204d) | 2009-01-05 → 2009-08-04 (+211d) | 1d → 5d |  | none → 17, 18, 19, 20, 21, 22, 14 | resources none → Chairs [21 chairs]; Displays [21 monitors]; General Contractor [200%]; Instructor workstations [1 desks]; PC systems [21 PCs]; Projectors [2 units]; Scanners [1 scanners]; Screens [2 units]; Tables [2 tables]; Whiteboards [4 boards]; Student workstations [20 desks]; Printers [1 printers] |
| 35 | Build Lab S325 | 2009-01-05 → 2009-07-16 (+192d) | 2009-01-05 → 2009-07-24 (+200d) | 1d → 7d | 0d → 6d | none → 17, 18, 19, 20, 21, 22, 14 | resources none → Chairs [26 chairs]; Displays [26 monitors]; General Contractor [200%]; Instructor workstations [1 desks]; PC systems [26 PCs]; Projectors [2 units]; Scanners [1 scanners]; Screens [2 units]; Tables [2 tables]; Whiteboards [4 boards]; Student workstations [25 desks]; Printers [1 printers] |
| 36 | Build Lab S326 | 2009-01-05 → 2009-07-06 (+182d) | 2009-01-05 → 2009-07-15 (+191d) | 1d → 8d | 0d → 13d | none → 17, 18, 19, 20, 21, 22, 14 | resources none → Chairs [31 chairs]; Displays [31 monitors]; General Contractor [200%]; Instructor workstations [1 desks]; PC systems [31 PCs]; Projectors [2 units]; Scanners [1 scanners]; Screens [2 units]; Tables [2 tables]; Whiteboards [4 boards]; Student workstations [30 desks]; Printers [1 printers] |
| 37 | **Sen Building** | 2009-01-05 → 2009-07-06 (+182d) | 2009-01-05 → 2009-07-31 (+207d) | 1d → 20d | 0d → 1d |  |  |
| 38 | Build Lab E210 | 2009-01-05 → 2009-07-27 (+203d) | 2009-01-05 → 2009-07-31 (+207d) | 1d → 5d | 0d → 1d | none → 17, 18, 19, 20, 21, 22, 15 | resources none → Chairs [21 chairs]; Displays [21 monitors]; General Contractor [200%]; Instructor workstations [1 desks]; PC systems [21 PCs]; Projectors [2 units]; Scanners [1 scanners]; Screens [2 units]; Tables [2 tables]; Whiteboards [4 boards]; Student workstations [20 desks]; Printers [1 printers] |
| 39 | Build Lab E211 | 2009-01-05 → 2009-07-16 (+192d) | 2009-01-05 → 2009-07-23 (+199d) | 1d → 6d | 0d → 7d | none → 17, 18, 19, 20, 21, 22, 15 | resources none → Chairs [26 chairs]; Displays [26 monitors]; General Contractor [200%]; Instructor workstations [1 desks]; PC systems [26 PCs]; Projectors [2 units]; Scanners [1 scanners]; Screens [2 units]; Tables [2 tables]; Whiteboards [4 boards]; Student workstations [25 desks]; Printers [1 printers] |
| 40 | Build Lab E212 | 2009-01-05 → 2009-07-06 (+182d) | 2009-01-05 → 2009-07-15 (+191d) | 1d → 8d | 0d → 13d | none → 17, 18, 19, 20, 21, 22, 15 | resources none → Chairs [31 chairs]; Displays [31 monitors]; General Contractor [200%]; Instructor workstations [1 desks]; PC systems [31 PCs]; Projectors [2 units]; Scanners [1 scanners]; Screens [2 units]; Tables [2 tables]; Whiteboards [4 boards]; Student workstations [30 desks]; Printers [1 printers] |
| 42 | **Commissioning** | 2009-01-05 → 2009-04-21 (+106d) | 2009-01-05 → 2009-08-21 (+228d) | 1d → 86d |  |  |  |
| 43 | Test all labs | 2009-01-05 → 2009-08-05 (+212d) | 2009-01-05 → 2009-08-07 (+214d) | 1d → 3d | 0d → 10d | none → 28, 29, 31, 32, 34, 35, 36, 38, 39, 40 | resources none → Project Manager [66.7%]; Information Systems Director [66.7%] |
| 44 | Produce as-built documents for all labs | 2009-01-05 → 2009-08-05 (+212d) | 2009-01-05 → 2009-08-21 (+228d) | 1d → 13d |  | none → 28, 29, 31, 32, 34, 35, 36, 38, 39, 40 | resources none → Interior Designer [15.4%]; Architect [15.4%]; Mechanical Consultant [15.4%]; Electrical Consultant [15.4%]; Security Consultant [15.4%]; Communications Consultant [15.4%]; General Contractor [15.4%] |
| 45 | Produce operations and maintenance manuals | 2009-01-05 → 2009-04-21 (+106d) | 2009-01-05 → 2009-05-19 (+134d) | 1d → 20d | 0d → 66d | none → 17, 18, 19, 20, 21, 22 | resources none → Information Systems Director [25%]; Facilities Manager [25%] |
| 48 | Project complete | 2009-01-05 → 2009-08-28 (+235d) | 2009-01-05 → 2009-08-28 (+235d) |  | 1d → 0d | none → 5 |  |

## Version 3 (saved 2009-09-02, file 3 - Allocations - Lab Build.mpp)

Last finish 2009-08-28 → 2009-02-27 (-182d).

Removed: 6 Project plan approved; 23 Lab requirements complete; 24 Construction documents complete; 25 Designs complete; 41 Lab construction started; 46 Operations manuals complete; 47 Labs complete

Changed:

| ID | Task | Start | Finish | Duration | Total float | Predecessors | Other |
| --- | --- | --- | --- | --- | --- | --- | --- |
| 2 | **Project Management** |  | 2009-08-28 → 2009-02-27 (-182d) | 166d → 40d |  |  |  |
| 3 | Plan project |  |  |  |  | 1 → none |  |
| 4 | Monitor & control project | 2009-03-02 → 2009-01-05 (-56d) | 2009-08-21 → 2009-01-30 (-203d) | 121d → 20d | 0d → 20d | 3 → none | resources Project Manager [19.8%]; Procurement Manager [5%]; Information Systems Director [5%]; Facilities Manager [5%] → Project Manager [20%]; Procurement Manager [5%]; Information Systems Director [5%]; Facilities Manager [5%] |
| 5 | Close project | 2009-08-24 → 2009-01-05 (-231d) | 2009-08-28 → 2009-01-09 (-231d) |  | 0d → 35d | 4, 38, 39, 40 → none |  |
| 6 | **Design** | 2009-03-02 → 2009-01-05 (-56d) | 2009-05-04 → 2009-01-30 (-94d) | 45d → 20d | 42d → 20d |  |  |
| 7 | Analyse lab requirements | 2009-03-02 → 2009-01-05 (-56d) | 2009-03-13 → 2009-01-16 (-56d) |  | 42d → 30d | 3 → none |  |
| 8 | Develop furniture specs | 2009-03-16 → 2009-01-05 (-70d) | 2009-04-03 → 2009-01-23 (-70d) |  | 42d → 25d | 7 → none |  |
| 9 | Develop equipment specs | 2009-03-16 → 2009-01-05 (-70d) | 2009-04-03 → 2009-01-23 (-70d) |  | 52d → 25d | 7 → none |  |
| 10 | **Design lab interiors** | 2009-04-06 → 2009-01-05 (-91d) | 2009-05-04 → 2009-01-30 (-94d) |  | 42d → 20d |  |  |
| 11 | Design lab interiors - Borlaug | 2009-04-06 → 2009-01-05 (-91d) | 2009-05-04 → 2009-01-30 (-94d) |  | 52d → 20d | 8 → none |  |
| 12 | Design lab interiors - Marquez | 2009-04-06 → 2009-01-05 (-91d) | 2009-05-04 → 2009-01-30 (-94d) |  | 50d → 20d | 8 → none |  |
| 13 | Design lab interiors - Salam | 2009-04-06 → 2009-01-05 (-91d) | 2009-05-04 → 2009-01-30 (-94d) |  | 42d → 20d | 8 → none |  |
| 14 | Design lab interiors - Sen | 2009-04-06 → 2009-01-05 (-91d) | 2009-05-04 → 2009-01-30 (-94d) |  | 43d → 20d | 8 → none |  |
| 15 | **Develop construction documents** | 2009-03-16 → 2009-01-05 (-70d) | 2009-04-20 → 2009-01-16 (-94d) | 25d → 10d | 52d → 30d |  |  |
| 16 | Develop architectural specs | 2009-03-16 → 2009-01-05 (-70d) | 2009-03-27 → 2009-01-16 (-70d) |  | 67d → 30d | 7 → none |  |
| 17 | Develop structural specs | 2009-03-30 → 2009-01-05 (-84d) | 2009-04-13 → 2009-01-16 (-87d) |  | 57d → 30d | 7 → none |  |
| 18 | Develop electrical specs | 2009-04-06 → 2009-01-05 (-91d) | 2009-04-20 → 2009-01-16 (-94d) |  | 52d → 30d | 9 → none |  |
| 19 | Develop mechanical specs | 2009-04-06 → 2009-01-05 (-91d) | 2009-04-20 → 2009-01-16 (-94d) |  | 52d → 30d | 9 → none |  |
| 20 | Develop communications/data specs | 2009-04-06 → 2009-01-05 (-91d) | 2009-04-20 → 2009-01-16 (-94d) |  | 52d → 30d | 9 → none |  |
| 21 | Develop security specs | 2009-03-16 → 2009-01-05 (-70d) | 2009-03-20 → 2009-01-09 (-70d) |  | 72d → 35d | 7 → none |  |
| 22 | **Construction** | 2009-07-06 → 2009-01-05 (-182d) | 2009-08-04 → 2009-01-14 (-202d) | 21d → 8d | 13d → 32d |  | constraint start no earlier than 2009-07-06 → none |
| 23 | **Borlaug Building** | 2009-07-06 → 2009-01-05 (-182d) | 2009-07-22 → 2009-01-14 (-189d) | 13d → 8d | 8d → 32d |  |  |
| 24 | Build Lab B107 | 2009-07-16 → 2009-01-05 (-192d) | 2009-07-22 → 2009-01-09 (-194d) |  | 8d → 35d | 11, 16, 17, 18, 19, 20, Lab requirements complete → none |  |
| 25 | Build Lab B108 | 2009-07-06 → 2009-01-05 (-182d) | 2009-07-15 → 2009-01-14 (-182d) |  | 13d → 32d | 11, 16, 17, 18, 19, 20, 21 → none |  |
| 26 | **Marquez Library** | 2009-07-06 → 2009-01-05 (-182d) | 2009-07-22 → 2009-01-13 (-190d) | 13d → 7d | 8d → 33d |  |  |
| 27 | Build Lab L315 | 2009-07-14 → 2009-01-05 (-190d) | 2009-07-22 → 2009-01-13 (-190d) |  | 8d → 33d | 16, 17, 18, 19, 20, 21, 12 → none |  |
| 28 | Build Lab L316 | 2009-07-06 → 2009-01-05 (-182d) | 2009-07-13 → 2009-01-12 (-182d) |  | 15d → 34d | 16, 17, 18, 19, 20, 21, 12 → none |  |
| 29 | **Salam Center** | 2009-07-06 → 2009-01-05 (-182d) | 2009-08-04 → 2009-01-14 (-202d) | 21d → 8d | 0d → 32d |  |  |
| 30 | Build Lab S324 | 2009-07-28 → 2009-01-05 (-204d) | 2009-08-04 → 2009-01-09 (-207d) |  | 0d → 35d | 16, 17, 18, 19, 20, 21, 13 → none |  |
| 31 | Build Lab S325 | 2009-07-16 → 2009-01-05 (-192d) | 2009-07-24 → 2009-01-13 (-192d) |  | 6d → 33d | 16, 17, 18, 19, 20, 21, 13 → none |  |
| 32 | Build Lab S326 | 2009-07-06 → 2009-01-05 (-182d) | 2009-07-15 → 2009-01-14 (-182d) |  | 13d → 32d | 16, 17, 18, 19, 20, 21, 13 → none |  |
| 33 | **Sen Building** | 2009-07-06 → 2009-01-05 (-182d) | 2009-07-31 → 2009-01-14 (-198d) | 20d → 8d | 1d → 32d |  |  |
| 34 | Build Lab E210 | 2009-07-27 → 2009-01-05 (-203d) | 2009-07-31 → 2009-01-09 (-203d) |  | 1d → 35d | 16, 17, 18, 19, 20, 21, 14 → none |  |
| 35 | Build Lab E211 | 2009-07-16 → 2009-01-05 (-192d) | 2009-07-23 → 2009-01-12 (-192d) |  | 7d → 34d | 16, 17, 18, 19, 20, 21, 14 → none |  |
| 36 | Build Lab E212 | 2009-07-06 → 2009-01-05 (-182d) | 2009-07-15 → 2009-01-14 (-182d) |  | 13d → 32d | 16, 17, 18, 19, 20, 21, 14 → none |  |
| 37 | **Commissioning** | 2009-04-21 → 2009-01-05 (-106d) | 2009-08-21 → 2009-01-30 (-203d) | 86d → 20d | 0d → 20d |  |  |
| 38 | Test all labs | 2009-08-05 → 2009-01-05 (-212d) | 2009-08-07 → 2009-01-06 (-213d) | 3d → 2d | 10d → 38d | 24, 25, 27, 28, 30, 31, 32, 34, 35, 36 → none | resources Project Manager [66.7%]; Information Systems Director [66.7%] → Project Manager; Information Systems Director |
| 39 | Produce as-built documents for all labs | 2009-08-05 → 2009-01-05 (-212d) | 2009-08-21 → 2009-01-23 (-210d) | 13d → 15d | 0d → 25d | 24, 25, 27, 28, 30, 31, 32, 34, 35, 36 → none | resources Interior Designer [15.4%]; Architect [15.4%]; Mechanical Consultant [15.4%]; Electrical Consultant [15.4%]; Security Consultant [15.4%]; Communications Consultant [15.4%]; General Contractor [15.4%] → Interior Designer [13.3%]; Architect [13.3%]; Mechanical Consultant [13.3%]; Electrical Consultant [13.3%]; Security Consultant [13.3%]; Communications Consultant [13.3%]; General Contractor [13.3%] |
| 40 | Produce operations and maintenance manuals | 2009-04-21 → 2009-01-05 (-106d) | 2009-05-19 → 2009-01-30 (-109d) |  | 66d → 20d | 16, 17, 18, 19, 20, 21 → none |  |
| 41 | Project complete | 2009-08-28 → 2009-01-05 (-235d) | 2009-08-28 → 2009-01-05 (-235d) |  | 0d → 1d | 5 → none |  |

## Version 4 (saved 2009-09-02, file 4 - Sequence - Lab Build.mpp)

Last finish 2009-02-27 → 2009-06-12 (+105d).

Changed:

| ID | Task | Start | Finish | Duration | Total float | Predecessors |
| --- | --- | --- | --- | --- | --- | --- |
| 2 | **Project Management** |  | 2009-02-27 → 2009-06-12 (+105d) | 40d → 113d |  |  |
| 3 | Plan project |  |  |  |  | none → 1 |
| 4 | Monitor & control project | 2009-01-05 → 2009-03-02 (+56d) | 2009-01-30 → 2009-03-27 (+56d) |  | 20d → 48d | none → 3 |
| 5 | Close project | 2009-01-05 → 2009-06-08 (+154d) | 2009-01-09 → 2009-06-12 (+154d) |  | 35d → 0d | none → 4, 38, 39, 40 |
| 6 | **Design** | 2009-01-05 → 2009-03-02 (+56d) | 2009-01-30 → 2009-05-04 (+94d) | 20d → 45d | 20d → 0d |  |
| 7 | Analyse lab requirements | 2009-01-05 → 2009-03-02 (+56d) | 2009-01-16 → 2009-03-13 (+56d) |  | 30d → 0d | none → 3 |
| 8 | Develop furniture specs | 2009-01-05 → 2009-03-16 (+70d) | 2009-01-23 → 2009-04-03 (+70d) |  | 25d → 0d | none → 7 |
| 9 | Develop equipment specs | 2009-01-05 → 2009-03-16 (+70d) | 2009-01-23 → 2009-04-03 (+70d) |  | 25d → 10d | none → 7 |
| 10 | **Design lab interiors** | 2009-01-05 → 2009-04-06 (+91d) | 2009-01-30 → 2009-05-04 (+94d) |  | 20d → 0d |  |
| 11 | Design lab interiors - Borlaug | 2009-01-05 → 2009-04-06 (+91d) | 2009-01-30 → 2009-05-04 (+94d) |  | 20d → 0d | none → 8 |
| 12 | Design lab interiors - Marquez | 2009-01-05 → 2009-04-06 (+91d) | 2009-01-30 → 2009-05-04 (+94d) |  | 20d → 1d | none → 8 |
| 13 | Design lab interiors - Salam | 2009-01-05 → 2009-04-06 (+91d) | 2009-01-30 → 2009-05-04 (+94d) |  | 20d → 0d | none → 8 |
| 14 | Design lab interiors - Sen | 2009-01-05 → 2009-04-06 (+91d) | 2009-01-30 → 2009-05-04 (+94d) |  | 20d → 0d | none → 8 |
| 15 | **Develop construction documents** | 2009-01-05 → 2009-03-16 (+70d) | 2009-01-16 → 2009-04-20 (+94d) | 10d → 25d | 30d → 10d |  |
| 16 | Develop architectural specs | 2009-01-05 → 2009-03-16 (+70d) | 2009-01-16 → 2009-03-27 (+70d) |  | 30d → 25d | none → 7 |
| 17 | Develop structural specs | 2009-01-05 → 2009-03-16 (+70d) | 2009-01-16 → 2009-03-27 (+70d) |  | 30d → 25d | none → 7 |
| 18 | Develop electrical specs | 2009-01-05 → 2009-04-06 (+91d) | 2009-01-16 → 2009-04-20 (+94d) |  | 30d → 10d | none → 9 |
| 19 | Develop mechanical specs | 2009-01-05 → 2009-04-06 (+91d) | 2009-01-16 → 2009-04-20 (+94d) |  | 30d → 10d | none → 9 |
| 20 | Develop communications/data specs | 2009-01-05 → 2009-04-06 (+91d) | 2009-01-16 → 2009-04-20 (+94d) |  | 30d → 10d | none → 9 |
| 21 | Develop security specs | 2009-01-05 → 2009-03-16 (+70d) | 2009-01-09 → 2009-03-20 (+70d) |  | 35d → 30d | none → 7 |
| 22 | **Construction** | 2009-01-05 → 2009-05-05 (+120d) | 2009-01-14 → 2009-05-14 (+120d) |  | 32d → 0d |  |
| 23 | **Borlaug Building** | 2009-01-05 → 2009-05-05 (+120d) | 2009-01-14 → 2009-05-14 (+120d) |  | 32d → 0d |  |
| 24 | Build Lab B107 | 2009-01-05 → 2009-05-05 (+120d) | 2009-01-09 → 2009-05-11 (+122d) |  | 35d → 3d | none → 11, 16, 17, 18, 19, 20, 21 |
| 25 | Build Lab B108 | 2009-01-05 → 2009-05-05 (+120d) | 2009-01-14 → 2009-05-14 (+120d) |  | 32d → 0d | none → 11, 16, 17, 18, 19, 20, 21 |
| 26 | **Marquez Library** | 2009-01-05 → 2009-05-05 (+120d) | 2009-01-13 → 2009-05-13 (+120d) |  | 33d → 1d |  |
| 27 | Build Lab L315 | 2009-01-05 → 2009-05-05 (+120d) | 2009-01-13 → 2009-05-13 (+120d) |  | 33d → 1d | none → 16, 17, 18, 19, 20, 21, 12 |
| 28 | Build Lab L316 | 2009-01-05 → 2009-05-05 (+120d) | 2009-01-12 → 2009-05-12 (+120d) |  | 34d → 2d | none → 16, 17, 18, 19, 20, 21, 12 |
| 29 | **Salam Center** | 2009-01-05 → 2009-05-05 (+120d) | 2009-01-14 → 2009-05-14 (+120d) |  | 32d → 0d |  |
| 30 | Build Lab S324 | 2009-01-05 → 2009-05-05 (+120d) | 2009-01-09 → 2009-05-11 (+122d) |  | 35d → 3d | none → 16, 17, 18, 19, 20, 21, 13 |
| 31 | Build Lab S325 | 2009-01-05 → 2009-05-05 (+120d) | 2009-01-13 → 2009-05-13 (+120d) |  | 33d → 1d | none → 16, 17, 18, 19, 20, 21, 13 |
| 32 | Build Lab S326 | 2009-01-05 → 2009-05-05 (+120d) | 2009-01-14 → 2009-05-14 (+120d) |  | 32d → 0d | none → 16, 17, 18, 19, 20, 21, 13 |
| 33 | **Sen Building** | 2009-01-05 → 2009-05-05 (+120d) | 2009-01-14 → 2009-05-14 (+120d) |  | 32d → 0d |  |
| 34 | Build Lab E210 | 2009-01-05 → 2009-05-05 (+120d) | 2009-01-09 → 2009-05-11 (+122d) |  | 35d → 3d | none → 16, 17, 18, 19, 20, 21, 14 |
| 35 | Build Lab E211 | 2009-01-05 → 2009-05-05 (+120d) | 2009-01-12 → 2009-05-12 (+120d) |  | 34d → 2d | none → 16, 17, 18, 19, 20, 21, 14 |
| 36 | Build Lab E212 | 2009-01-05 → 2009-05-05 (+120d) | 2009-01-14 → 2009-05-14 (+120d) |  | 32d → 0d | none → 16, 17, 18, 19, 20, 21, 14 |
| 37 | **Commissioning** | 2009-01-05 → 2009-04-21 (+106d) | 2009-01-30 → 2009-06-05 (+126d) | 20d → 33d | 20d → 0d |  |
| 38 | Test all labs | 2009-01-05 → 2009-05-15 (+130d) | 2009-01-06 → 2009-05-19 (+133d) |  | 38d → 13d | none → 24, 25, 27, 28, 30, 31, 32, 34, 35, 36 |
| 39 | Produce as-built documents for all labs | 2009-01-05 → 2009-05-15 (+130d) | 2009-01-23 → 2009-06-05 (+133d) |  | 25d → 0d | none → 24, 25, 27, 28, 30, 31, 32, 34, 35, 36 |
| 40 | Produce operations and maintenance manuals | 2009-01-05 → 2009-04-21 (+106d) | 2009-01-30 → 2009-05-19 (+109d) |  | 20d → 13d | none → 16, 17, 18, 19, 20, 21 |
| 41 | Project complete | 2009-01-05 → 2009-06-12 (+158d) | 2009-01-05 → 2009-06-12 (+158d) |  | 1d → 0d | none → 5 |

## Version 5 (data date 2009-06-26, saved 2009-09-02, file 8 - Control - Lab Build.mpp)

Last finish 2009-06-12 → 2009-08-14 (+63d). Complete tasks 0 → 18.

Added:

| ID | Task | Duration | Start | Finish | Predecessors | Constraint |
| --- | --- | --- | --- | --- | --- | --- |
| 6 | Project plan approved | 0d | 2009-03-27 A | 2009-03-27 A | 3 |  |
| 23 | Lab requirements complete | 0d | 2009-04-03 A | 2009-04-03 A | 8 |  |
| 24 | Construction documents complete | 0d | 2009-06-05 A | 2009-06-05 A | 17, 18, 19, 20, 21, 22 |  |
| 25 | Designs complete | 0d | 2009-06-26 | 2009-06-26 | 9, 10, 16, 13, 14, 15, 17, 18, 19, 20, 21, 22 | start no earlier than 2009-06-26 |
| 41 | Lab construction started | 0d | 2009-07-06 | 2009-07-06 |  |  |
| 46 | Operations manuals complete | 0d | 2009-08-06 | 2009-08-06 | 45 |  |
| 47 | Labs complete | 0d | 2009-08-07 | 2009-08-07 | 43 |  |

Changed:

| ID | Task | Start | Finish | Duration | Complete | Total float | Predecessors | Other |
| --- | --- | --- | --- | --- | --- | --- | --- | --- |
| 1 | Project approved | 2009-01-05 A | 2009-01-05 A |  | 0% → 100% | 0d → none |  | baseline start none → 2009-01-05; baseline finish none → 2009-01-05 |
| 2 | **Project Management** | 2009-01-05 A | 2009-06-12 → 2009-08-14 (+63d) | 113d → 156d | 0% → 81% |  |  | baseline start none → 2009-01-05; baseline finish none → 2009-08-28 |
| 3 | Plan project | 2009-01-05 A | 2009-02-27 → 2009-03-13 A (+14d) | 40d → 50d | 0% → 100% | 0d → none |  | resources Project Manager [37.5%]; Procurement Manager [12.5%]; Facilities Manager [12.5%]; Information Systems Director [12.5%]; Architect; General Contractor; Mechanical Consultant; Electrical Consultant; Communications Consultant; Security Consultant; Interior Designer → Project Manager [37.5%]; Procurement Manager [12.5%]; Facilities Manager [6%]; Information Systems Director [12.5%]; Architect; General Contractor; Mechanical Consultant; Electrical Consultant; Communications Consultant; Security Consultant; Interior Designer; baseline start none → 2009-01-05; baseline finish none → 2009-02-27 |
| 4 | Monitor & control project | 2009-03-02 → 2009-03-16 A (+14d) | 2009-03-27 → 2009-08-07 (+133d) | 20d → 101d | 0% → 76% | 48d → 0d |  | resources Project Manager [20%]; Procurement Manager [5%]; Information Systems Director [5%]; Facilities Manager [5%] → Project Manager [19.8%]; Procurement Manager [5%]; Information Systems Director [5%]; Facilities Manager [5%]; Facilities Director [5%]; baseline start none → 2009-03-02; baseline finish none → 2009-08-21 |
| 5 | Close project | 2009-06-08 → 2009-08-07 (+60d) | 2009-06-12 → 2009-08-14 (+63d) |  |  |  |  | resources Project Manager; Information Systems Director; Facilities Manager; Procurement Manager; Architect; General Contractor; Interior Designer → Project Manager; Information Systems Director; Facilities Manager; Procurement Manager; Architect; General Contractor; Interior Designer; Facilities Director; baseline start none → 2009-08-24; baseline finish none → 2009-08-28 |
| 7 | **Design** | 2009-03-02 → 2009-03-16 A (+14d) | 2009-05-04 → 2009-06-26 A (+53d) | 45d → 73d | 0% → 100% | 0d → none |  | baseline start none → 2009-03-02; baseline finish none → 2009-05-04 |
| 8 | Analyse lab requirements | 2009-03-02 → 2009-03-16 A (+14d) | 2009-03-13 → 2009-04-03 A (+21d) | 10d → 15d | 0% → 100% | 0d → none |  | resources Information Systems Director [20%]; Facilities Manager [20%]; Procurement Manager [20%]; Interior Designer [20%]; Architect [20%]; Mechanical Consultant [20%]; Electrical Consultant [20%]; Security Consultant [20%]; Communications Consultant [20%] → Information Systems Director [20%]; Facilities Manager [6.7%]; Procurement Manager [20%]; Interior Designer [20%]; Architect [20%]; Mechanical Consultant [20%]; Electrical Consultant [20%]; Security Consultant [20%]; Communications Consultant [20%]; baseline start none → 2009-03-02; baseline finish none → 2009-03-13 |
| 9 | Develop furniture specs | 2009-03-16 → 2009-04-06 A (+21d) | 2009-04-03 → 2009-05-04 A (+31d) | 15d → 20d | 0% → 100% | 0d → none |  | resources Facilities Manager [6.7%]; Interior Designer [33.3%] → Facilities Manager [6.7%]; Interior Designer [25%]; baseline start none → 2009-03-16; baseline finish none → 2009-04-03 |
| 10 | Develop equipment specs | 2009-03-16 → 2009-04-06 A (+21d) | 2009-04-03 → 2009-04-27 A (+24d) |  | 0% → 100% | 10d → none |  | baseline start none → 2009-03-16; baseline finish none → 2009-04-03 |
| 11 | **Design lab interiors** | 2009-04-06 → 2009-05-05 A (+29d) | 2009-05-04 → 2009-06-26 A (+53d) | 20d → 38d | 0% → 100% | 0d → none |  | baseline start none → 2009-04-06; baseline finish none → 2009-05-04 |
| 12 | Design lab interiors - Borlaug | 2009-04-06 → 2009-05-05 A (+29d) | 2009-05-04 → 2009-06-12 A (+39d) | 20d → 28d | 0% → 100% | 0d → none |  | resources Interior Designer [20%] → Interior Designer [50%]; baseline start none → 2009-04-06; baseline finish none → 2009-05-04 |
| 13 | Design lab interiors - Marquez | 2009-04-06 → 2009-05-05 A (+29d) | 2009-05-04 → 2009-06-19 A (+46d) | 20d → 33d | 0% → 100% | 1d → none |  | resources Interior Designer [20%] → Interior Designer [30.8%]; baseline start none → 2009-04-06; baseline finish none → 2009-05-04 |
| 14 | Design lab interiors - Salam | 2009-04-06 → 2009-05-05 A (+29d) | 2009-05-04 → 2009-06-26 A (+53d) | 20d → 38d | 0% → 100% | 0d → none |  | resources Interior Designer [25%] → Interior Designer [27.8%]; baseline start none → 2009-04-06; baseline finish none → 2009-05-04 |
| 15 | Design lab interiors - Sen | 2009-04-06 → 2009-05-05 A (+29d) | 2009-05-04 → 2009-06-26 A (+53d) | 20d → 38d | 0% → 100% | 0d → none |  | resources Interior Designer [25%] → Interior Designer [27.8%]; baseline start none → 2009-04-06; baseline finish none → 2009-05-04 |
| 16 | **Develop construction documents** | 2009-03-16 → 2009-04-06 A (+21d) | 2009-04-20 → 2009-06-05 A (+46d) | 25d → 43d | 0% → 100% | 10d → none |  | baseline start none → 2009-03-16; baseline finish none → 2009-04-20 |
| 17 | Develop architectural specs | 2009-03-16 → 2009-04-06 A (+21d) | 2009-03-27 → 2009-05-15 A (+49d) | 10d → 29d | 0% → 100% | 25d → none |  | resources Architect → Architect [34.5%]; baseline start none → 2009-03-16; baseline finish none → 2009-03-27 |
| 18 | Develop structural specs | 2009-03-16 → 2009-04-21 A (+36d) | 2009-03-27 → 2009-05-29 A (+63d) | 10d → 28d | 0% → 100% | 25d → none |  | resources Architect → Architect [35.7%]; baseline start none → 2009-03-30; baseline finish none → 2009-04-13 |
| 19 | Develop electrical specs | 2009-04-06 → 2009-04-28 A (+22d) | 2009-04-20 → 2009-05-29 A (+39d) | 10d → 23d | 0% → 100% | 10d → none |  | resources Electrical Consultant → Electrical Consultant [43.5%]; baseline start none → 2009-04-06; baseline finish none → 2009-04-20 |
| 20 | Develop mechanical specs | 2009-04-06 → 2009-04-28 A (+22d) | 2009-04-20 → 2009-06-05 A (+46d) | 10d → 28d | 0% → 100% | 10d → none |  | resources Mechanical Consultant → Mechanical Consultant [35.7%]; baseline start none → 2009-04-06; baseline finish none → 2009-04-20 |
| 21 | Develop communications/data specs | 2009-04-06 → 2009-04-28 A (+22d) | 2009-04-20 → 2009-06-05 A (+46d) | 10d → 28d | 0% → 100% | 10d → none |  | resources Communications Consultant → Communications Consultant [35.7%]; baseline start none → 2009-04-06; baseline finish none → 2009-04-20 |
| 22 | Develop security specs | 2009-03-16 → 2009-04-06 A (+21d) | 2009-03-20 → 2009-04-13 A (+24d) |  | 0% → 100% | 30d → none |  | baseline start none → 2009-03-16; baseline finish none → 2009-03-20 |
| 26 | **Construction** | 2009-05-05 → 2009-07-06 (+62d) | 2009-05-14 → 2009-08-04 (+82d) | 8d → 21d |  | 0d → 8d |  | constraint none → start no earlier than 2009-07-06; baseline start none → 2009-07-06; baseline finish none → 2009-08-04 |
| 27 | **Borlaug Building** | 2009-05-05 → 2009-07-06 (+62d) | 2009-05-14 → 2009-07-22 (+69d) | 8d → 13d |  | 0d → 8d |  | baseline start none → 2009-07-06; baseline finish none → 2009-07-22 |
| 28 | Build Lab B107 | 2009-05-05 → 2009-07-16 (+72d) | 2009-05-11 → 2009-07-22 (+72d) |  |  | 3d → 8d | 12, 17, 18, 19, 20, 21, 22 → 12, 17, 18, 19, 20, 21, 23 | baseline start none → 2009-07-16; baseline finish none → 2009-07-22 |
| 29 | Build Lab B108 | 2009-05-05 → 2009-07-06 (+62d) | 2009-05-14 → 2009-07-15 (+62d) |  |  | 0d → 13d |  | baseline start none → 2009-07-06; baseline finish none → 2009-07-15 |
| 30 | **Marquez Library** | 2009-05-05 → 2009-07-06 (+62d) | 2009-05-13 → 2009-07-22 (+70d) | 7d → 13d |  | 1d → 8d |  | baseline start none → 2009-07-06; baseline finish none → 2009-07-22 |
| 31 | Build Lab L315 | 2009-05-05 → 2009-07-14 (+70d) | 2009-05-13 → 2009-07-22 (+70d) |  |  | 1d → 8d |  | baseline start none → 2009-07-14; baseline finish none → 2009-07-22 |
| 32 | Build Lab L316 | 2009-05-05 → 2009-07-06 (+62d) | 2009-05-12 → 2009-07-13 (+62d) |  |  | 2d → 15d |  | baseline start none → 2009-07-06; baseline finish none → 2009-07-13 |
| 33 | **Salam Center** | 2009-05-05 → 2009-07-06 (+62d) | 2009-05-14 → 2009-08-04 (+82d) | 8d → 21d |  |  |  | baseline start none → 2009-07-06; baseline finish none → 2009-08-04 |
| 34 | Build Lab S324 | 2009-05-05 → 2009-07-28 (+84d) | 2009-05-11 → 2009-08-04 (+85d) |  |  | 3d → 0d |  | baseline start none → 2009-07-28; baseline finish none → 2009-08-04 |
| 35 | Build Lab S325 | 2009-05-05 → 2009-07-16 (+72d) | 2009-05-13 → 2009-07-24 (+72d) |  |  | 1d → 6d |  | baseline start none → 2009-07-16; baseline finish none → 2009-07-24 |
| 36 | Build Lab S326 | 2009-05-05 → 2009-07-06 (+62d) | 2009-05-14 → 2009-07-15 (+62d) |  |  | 0d → 13d |  | baseline start none → 2009-07-06; baseline finish none → 2009-07-15 |
| 37 | **Sen Building** | 2009-05-05 → 2009-07-06 (+62d) | 2009-05-14 → 2009-07-31 (+78d) | 8d → 20d |  | 0d → 1d |  | baseline start none → 2009-07-06; baseline finish none → 2009-07-31 |
| 38 | Build Lab E210 | 2009-05-05 → 2009-07-27 (+83d) | 2009-05-11 → 2009-07-31 (+81d) |  |  | 3d → 1d |  | baseline start none → 2009-07-27; baseline finish none → 2009-07-31 |
| 39 | Build Lab E211 | 2009-05-05 → 2009-07-16 (+72d) | 2009-05-12 → 2009-07-23 (+72d) |  |  | 2d → 7d |  | baseline start none → 2009-07-16; baseline finish none → 2009-07-23 |
| 40 | Build Lab E212 | 2009-05-05 → 2009-07-06 (+62d) | 2009-05-14 → 2009-07-15 (+62d) |  |  | 0d → 13d |  | baseline start none → 2009-07-06; baseline finish none → 2009-07-15 |
| 42 | **Commissioning** | 2009-04-21 → 2009-06-26 (+66d) | 2009-06-05 → 2009-08-07 (+63d) | 33d → 28d |  |  |  | baseline start none → 2009-04-21; baseline finish none → 2009-08-21 |
| 43 | Test all labs | 2009-05-15 → 2009-08-05 (+82d) | 2009-05-19 → 2009-08-07 (+80d) | 2d → 3d |  | 13d → 0d |  | resources Project Manager; Information Systems Director → Project Manager [66.7%]; Information Systems Director [66.7%]; baseline start none → 2009-08-05; baseline finish none → 2009-08-07 |
| 44 | Produce as-built documents for all labs | 2009-05-15 → 2009-07-16 (+62d) | 2009-06-05 → 2009-08-04 (+60d) | 15d → 13d |  | 0d → 3d | 28, 29, 31, 32, 34, 35, 36, 38, 39, 40 → 28FF, 29FF, 31FF, 32FF, 34FF, 35FF, 36FF, 38FF, 39FF, 40FF | resources Interior Designer [13.3%]; Architect [13.3%]; Mechanical Consultant [13.3%]; Electrical Consultant [13.3%]; Security Consultant [13.3%]; Communications Consultant [13.3%]; General Contractor [13.3%] → Interior Designer [15.4%]; Architect [15.4%]; Mechanical Consultant [15.4%]; Electrical Consultant [15.4%]; Security Consultant [15.4%]; Communications Consultant [15.4%]; General Contractor [15.4%]; baseline start none → 2009-08-05; baseline finish none → 2009-08-21 |
| 45 | Produce operations and maintenance manuals | 2009-04-21 → 2009-06-26 (+66d) | 2009-05-19 → 2009-08-06 (+79d) | 20d → 27d |  | 13d → 1d |  | constraint none → start no earlier than 2009-06-26; resources Information Systems Director [25%]; Facilities Manager [25%] → Information Systems Director [27.8%]; Facilities Manager [25%]; Facilities Director [25%]; baseline start none → 2009-04-21; baseline finish none → 2009-05-19 |
| 48 | Project complete | 2009-06-12 → 2009-08-14 (+63d) | 2009-06-12 → 2009-08-14 (+63d) |  |  |  |  | baseline start none → 2009-08-28; baseline finish none → 2009-08-28 |

## Version 6 (saved 2009-09-02, file 6 - Budget Baseline - Lab Build.mpp)

Last finish 2009-08-14 → 2009-08-28 (+14d). Complete tasks 18 → 0.

Changed:

| ID | Task | Start | Finish | Duration | Complete | Total float | Predecessors | Other |
| --- | --- | --- | --- | --- | --- | --- | --- | --- |
| 1 | Project approved | 2009-01-05 A → 2009-01-05 | 2009-01-05 A → 2009-01-05 |  | 100% → 0% | none → 0d |  |  |
| 2 | **Project Management** | 2009-01-05 A → 2009-01-05 | 2009-08-14 → 2009-08-28 (+14d) | 156d → 166d | 81% → 0% |  |  |  |
| 3 | Plan project | 2009-01-05 A → 2009-01-05 | 2009-03-13 A → 2009-02-27 (-14d) | 50d → 40d | 100% → 0% | none → 0d |  | resources Project Manager [37.5%]; Procurement Manager [12.5%]; Facilities Manager [6%]; Information Systems Director [12.5%]; Architect; General Contractor; Mechanical Consultant; Electrical Consultant; Communications Consultant; Security Consultant; Interior Designer → Project Manager [37.5%]; Procurement Manager [12.5%]; Facilities Manager [12.5%]; Information Systems Director [12.5%]; Architect; General Contractor; Mechanical Consultant; Electrical Consultant; Communications Consultant; Security Consultant; Interior Designer |
| 4 | Monitor & control project | 2009-03-16 A → 2009-03-02 (-14d) | 2009-08-07 → 2009-08-21 (+14d) | 101d → 121d | 76% → 0% |  |  | resources Project Manager [19.8%]; Procurement Manager [5%]; Information Systems Director [5%]; Facilities Manager [5%]; Facilities Director [5%] → Project Manager [19.8%]; Procurement Manager [5%]; Information Systems Director [5%]; Facilities Manager [5%] |
| 5 | Close project | 2009-08-07 → 2009-08-24 (+17d) | 2009-08-14 → 2009-08-28 (+14d) |  |  |  |  | resources Project Manager; Information Systems Director; Facilities Manager; Procurement Manager; Architect; General Contractor; Interior Designer; Facilities Director → Project Manager; Information Systems Director; Facilities Manager; Procurement Manager; Architect; General Contractor; Interior Designer |
| 6 | Project plan approved | 2009-03-27 A → 2009-02-27 (-28d) | 2009-03-27 A → 2009-02-27 (-28d) |  | 100% → 0% | none → 126d |  |  |
| 7 | **Design** | 2009-03-16 A → 2009-03-02 (-14d) | 2009-06-26 A → 2009-05-04 (-53d) | 73d → 45d | 100% → 0% | none → 42d |  |  |
| 8 | Analyse lab requirements | 2009-03-16 A → 2009-03-02 (-14d) | 2009-04-03 A → 2009-03-13 (-21d) | 15d → 10d | 100% → 0% | none → 42d |  | resources Information Systems Director [20%]; Facilities Manager [6.7%]; Procurement Manager [20%]; Interior Designer [20%]; Architect [20%]; Mechanical Consultant [20%]; Electrical Consultant [20%]; Security Consultant [20%]; Communications Consultant [20%] → Information Systems Director [20%]; Facilities Manager [20%]; Procurement Manager [20%]; Interior Designer [20%]; Architect [20%]; Mechanical Consultant [20%]; Electrical Consultant [20%]; Security Consultant [20%]; Communications Consultant [20%] |
| 9 | Develop furniture specs | 2009-04-06 A → 2009-03-16 (-21d) | 2009-05-04 A → 2009-04-03 (-31d) | 20d → 15d | 100% → 0% | none → 42d |  | resources Facilities Manager [6.7%]; Interior Designer [25%] → Facilities Manager [6.7%]; Interior Designer [33.3%] |
| 10 | Develop equipment specs | 2009-04-06 A → 2009-03-16 (-21d) | 2009-04-27 A → 2009-04-03 (-24d) |  | 100% → 0% | none → 52d |  |  |
| 11 | **Design lab interiors** | 2009-05-05 A → 2009-04-06 (-29d) | 2009-06-26 A → 2009-05-04 (-53d) | 38d → 20d | 100% → 0% | none → 42d |  |  |
| 12 | Design lab interiors - Borlaug | 2009-05-05 A → 2009-04-06 (-29d) | 2009-06-12 A → 2009-05-04 (-39d) | 28d → 20d | 100% → 0% | none → 52d |  | resources Interior Designer [50%] → Interior Designer [20%] |
| 13 | Design lab interiors - Marquez | 2009-05-05 A → 2009-04-06 (-29d) | 2009-06-19 A → 2009-05-04 (-46d) | 33d → 20d | 100% → 0% | none → 50d |  | resources Interior Designer [30.8%] → Interior Designer [20%] |
| 14 | Design lab interiors - Salam | 2009-05-05 A → 2009-04-06 (-29d) | 2009-06-26 A → 2009-05-04 (-53d) | 38d → 20d | 100% → 0% | none → 42d |  | resources Interior Designer [27.8%] → Interior Designer [25%] |
| 15 | Design lab interiors - Sen | 2009-05-05 A → 2009-04-06 (-29d) | 2009-06-26 A → 2009-05-04 (-53d) | 38d → 20d | 100% → 0% | none → 43d |  | resources Interior Designer [27.8%] → Interior Designer [25%] |
| 16 | **Develop construction documents** | 2009-04-06 A → 2009-03-16 (-21d) | 2009-06-05 A → 2009-04-20 (-46d) | 43d → 25d | 100% → 0% | none → 52d |  |  |
| 17 | Develop architectural specs | 2009-04-06 A → 2009-03-16 (-21d) | 2009-05-15 A → 2009-03-27 (-49d) | 29d → 10d | 100% → 0% | none → 67d |  | resources Architect [34.5%] → Architect |
| 18 | Develop structural specs | 2009-04-21 A → 2009-03-30 (-22d) | 2009-05-29 A → 2009-04-13 (-46d) | 28d → 10d | 100% → 0% | none → 57d |  | resources Architect [35.7%] → Architect |
| 19 | Develop electrical specs | 2009-04-28 A → 2009-04-06 (-22d) | 2009-05-29 A → 2009-04-20 (-39d) | 23d → 10d | 100% → 0% | none → 52d |  | resources Electrical Consultant [43.5%] → Electrical Consultant |
| 20 | Develop mechanical specs | 2009-04-28 A → 2009-04-06 (-22d) | 2009-06-05 A → 2009-04-20 (-46d) | 28d → 10d | 100% → 0% | none → 52d |  | resources Mechanical Consultant [35.7%] → Mechanical Consultant |
| 21 | Develop communications/data specs | 2009-04-28 A → 2009-04-06 (-22d) | 2009-06-05 A → 2009-04-20 (-46d) | 28d → 10d | 100% → 0% | none → 52d |  | resources Communications Consultant [35.7%] → Communications Consultant |
| 22 | Develop security specs | 2009-04-06 A → 2009-03-16 (-21d) | 2009-04-13 A → 2009-03-20 (-24d) |  | 100% → 0% | none → 72d |  |  |
| 23 | Lab requirements complete | 2009-04-03 A → 2009-03-13 (-21d) | 2009-04-03 A → 2009-03-13 (-21d) |  | 100% → 0% | none → 87d |  |  |
| 24 | Construction documents complete | 2009-06-05 A → 2009-04-20 (-46d) | 2009-06-05 A → 2009-04-20 (-46d) |  | 100% → 0% | none → 91d |  |  |
| 25 | Designs complete | 2009-06-26 → 2009-05-04 (-53d) | 2009-06-26 → 2009-05-04 (-53d) |  |  | 33d → 81d |  | constraint start no earlier than 2009-06-26 → none |
| 42 | **Commissioning** | 2009-06-26 → 2009-04-21 (-66d) | 2009-08-07 → 2009-08-21 (+14d) | 28d → 86d |  |  |  |  |
| 44 | Produce as-built documents for all labs | 2009-07-16 → 2009-08-05 (+20d) | 2009-08-04 → 2009-08-21 (+17d) |  |  | 3d → 0d | 28FF, 29FF, 31FF, 32FF, 34FF, 35FF, 36FF, 38FF, 39FF, 40FF → 28, 29, 31, 32, 34, 35, 36, 38, 39, 40 |  |
| 45 | Produce operations and maintenance manuals | 2009-06-26 → 2009-04-21 (-66d) | 2009-08-06 → 2009-05-19 (-79d) | 27d → 20d |  | 1d → 66d |  | constraint start no earlier than 2009-06-26 → none; resources Information Systems Director [27.8%]; Facilities Manager [25%]; Facilities Director [25%] → Information Systems Director [25%]; Facilities Manager [25%] |
| 46 | Operations manuals complete | 2009-08-06 → 2009-05-19 (-79d) | 2009-08-06 → 2009-05-19 (-79d) |  |  | 6d → 71d |  |  |
| 48 | Project complete | 2009-08-14 → 2009-08-28 (+14d) | 2009-08-14 → 2009-08-28 (+14d) |  |  |  |  |  |

## Version 7 (data date 2009-06-26, saved 2009-09-02, file 7 - Tracked - Lab Build.mpp)

Last finish 2009-08-28 → 2009-09-14 (+17d). Complete tasks 0 → 18.

Changed:

| ID | Task | Start | Finish | Duration | Complete | Total float | Other |
| --- | --- | --- | --- | --- | --- | --- | --- |
| 1 | Project approved | 2009-01-05 A | 2009-01-05 A |  | 0% → 100% | 0d → none |  |
| 2 | **Project Management** | 2009-01-05 A | 2009-08-28 → 2009-09-14 (+17d) | 166d → 176d | 0% → 69% | 0d → -5d |  |
| 3 | Plan project | 2009-01-05 A | 2009-02-27 → 2009-03-13 A (+14d) | 40d → 50d | 0% → 100% | 0d → none | resources Project Manager [37.5%]; Procurement Manager [12.5%]; Facilities Manager [12.5%]; Information Systems Director [12.5%]; Architect; General Contractor; Mechanical Consultant; Electrical Consultant; Communications Consultant; Security Consultant; Interior Designer → Project Manager [37.5%]; Procurement Manager [12.5%]; Facilities Manager [6%]; Information Systems Director [12.5%]; Architect; General Contractor; Mechanical Consultant; Electrical Consultant; Communications Consultant; Security Consultant; Interior Designer |
| 4 | Monitor & control project | 2009-03-02 → 2009-03-16 A (+14d) | 2009-08-21 → 2009-09-04 (+14d) |  | 0% → 59% | 0d → -9d |  |
| 5 | Close project | 2009-08-24 → 2009-09-08 (+15d) | 2009-08-28 → 2009-09-14 (+17d) |  |  | 0d → -9d |  |
| 6 | Project plan approved | 2009-02-27 → 2009-03-27 A (+28d) | 2009-02-27 → 2009-03-27 A (+28d) |  | 0% → 100% | 126d → none |  |
| 7 | **Design** | 2009-03-02 → 2009-03-16 A (+14d) | 2009-05-04 → 2009-06-26 A (+53d) | 45d → 73d | 0% → 100% | 42d → none |  |
| 8 | Analyse lab requirements | 2009-03-02 → 2009-03-16 A (+14d) | 2009-03-13 → 2009-04-03 A (+21d) | 10d → 15d | 0% → 100% | 42d → none | resources Information Systems Director [20%]; Facilities Manager [20%]; Procurement Manager [20%]; Interior Designer [20%]; Architect [20%]; Mechanical Consultant [20%]; Electrical Consultant [20%]; Security Consultant [20%]; Communications Consultant [20%] → Information Systems Director [20%]; Facilities Manager [6.7%]; Procurement Manager [20%]; Interior Designer [20%]; Architect [20%]; Mechanical Consultant [20%]; Electrical Consultant [20%]; Security Consultant [20%]; Communications Consultant [20%] |
| 9 | Develop furniture specs | 2009-03-16 → 2009-04-06 A (+21d) | 2009-04-03 → 2009-05-04 A (+31d) | 15d → 20d | 0% → 100% | 42d → none | resources Facilities Manager [6.7%]; Interior Designer [33.3%] → Facilities Manager [6.7%]; Interior Designer [25%] |
| 10 | Develop equipment specs | 2009-03-16 → 2009-04-06 A (+21d) | 2009-04-03 → 2009-04-27 A (+24d) |  | 0% → 100% | 52d → none |  |
| 11 | **Design lab interiors** | 2009-04-06 → 2009-05-05 A (+29d) | 2009-05-04 → 2009-06-26 A (+53d) | 20d → 38d | 0% → 100% | 42d → none |  |
| 12 | Design lab interiors - Borlaug | 2009-04-06 → 2009-05-05 A (+29d) | 2009-05-04 → 2009-06-12 A (+39d) | 20d → 28d | 0% → 100% | 52d → none | resources Interior Designer [20%] → Interior Designer [50%] |
| 13 | Design lab interiors - Marquez | 2009-04-06 → 2009-05-05 A (+29d) | 2009-05-04 → 2009-06-19 A (+46d) | 20d → 33d | 0% → 100% | 50d → none | resources Interior Designer [20%] → Interior Designer [30.8%] |
| 14 | Design lab interiors - Salam | 2009-04-06 → 2009-05-05 A (+29d) | 2009-05-04 → 2009-06-26 A (+53d) | 20d → 38d | 0% → 100% | 42d → none | resources Interior Designer [25%] → Interior Designer [27.8%] |
| 15 | Design lab interiors - Sen | 2009-04-06 → 2009-05-05 A (+29d) | 2009-05-04 → 2009-06-26 A (+53d) | 20d → 38d | 0% → 100% | 43d → none | resources Interior Designer [25%] → Interior Designer [27.8%] |
| 16 | **Develop construction documents** | 2009-03-16 → 2009-04-06 A (+21d) | 2009-04-20 → 2009-06-05 A (+46d) | 25d → 43d | 0% → 100% | 52d → none |  |
| 17 | Develop architectural specs | 2009-03-16 → 2009-04-06 A (+21d) | 2009-03-27 → 2009-05-15 A (+49d) | 10d → 29d | 0% → 100% | 67d → none | resources Architect → Architect [34.5%] |
| 18 | Develop structural specs | 2009-03-30 → 2009-04-21 A (+22d) | 2009-04-13 → 2009-05-29 A (+46d) | 10d → 28d | 0% → 100% | 57d → none | resources Architect → Architect [35.7%] |
| 19 | Develop electrical specs | 2009-04-06 → 2009-04-28 A (+22d) | 2009-04-20 → 2009-05-29 A (+39d) | 10d → 23d | 0% → 100% | 52d → none | resources Electrical Consultant → Electrical Consultant [43.5%] |
| 20 | Develop mechanical specs | 2009-04-06 → 2009-04-28 A (+22d) | 2009-04-20 → 2009-06-05 A (+46d) | 10d → 28d | 0% → 100% | 52d → none | resources Mechanical Consultant → Mechanical Consultant [35.7%] |
| 21 | Develop communications/data specs | 2009-04-06 → 2009-04-28 A (+22d) | 2009-04-20 → 2009-06-05 A (+46d) | 10d → 28d | 0% → 100% | 52d → none | resources Communications Consultant → Communications Consultant [35.7%] |
| 22 | Develop security specs | 2009-03-16 → 2009-04-06 A (+21d) | 2009-03-20 → 2009-04-13 A (+24d) |  | 0% → 100% | 72d → none |  |
| 23 | Lab requirements complete | 2009-03-13 → 2009-04-03 A (+21d) | 2009-03-13 → 2009-04-03 A (+21d) |  | 0% → 100% | 87d → none |  |
| 24 | Construction documents complete | 2009-04-20 → 2009-06-05 A (+46d) | 2009-04-20 → 2009-06-05 A (+46d) |  | 0% → 100% | 91d → none |  |
| 25 | Designs complete | 2009-05-04 → 2009-06-26 (+53d) | 2009-05-04 → 2009-06-26 (+53d) |  |  | 81d → 53d |  |
| 42 | **Commissioning** | 2009-04-21 → 2009-06-08 (+48d) |  | 86d → 53d |  | 0d → 1d |  |
| 45 | Produce operations and maintenance manuals | 2009-04-21 → 2009-06-08 (+48d) | 2009-05-19 → 2009-07-17 (+59d) | 20d → 25d |  | 66d → 25d |  |
| 46 | Operations manuals complete | 2009-05-19 → 2009-07-17 (+59d) | 2009-05-19 → 2009-07-17 (+59d) |  |  | 71d → 39d |  |
| 48 | Project complete | 2009-08-28 → 2009-09-14 (+17d) | 2009-08-28 → 2009-09-14 (+17d) |  |  | 0d → -9d |  |

## Version 8 (data date 2009-08-14, saved 2009-09-02, file 9 - Close - Lab Build.mpp)

Last finish 2009-09-14 → 2009-08-14 (-31d). Complete tasks 18 → 38.

Changed:

| ID | Task | Start | Finish | Duration | Complete | Total float | Predecessors | Other |
| --- | --- | --- | --- | --- | --- | --- | --- | --- |
| 2 | **Project Management** |  | 2009-09-14 → 2009-08-14 A (-31d) | 176d → 156d | 69% → 100% | -5d → none |  |  |
| 4 | Monitor & control project |  | 2009-09-04 → 2009-08-07 A (-28d) | 121d → 101d | 59% → 100% | -9d → none |  | resources Project Manager [19.8%]; Procurement Manager [5%]; Information Systems Director [5%]; Facilities Manager [5%] → Project Manager [19.8%]; Procurement Manager [5%]; Information Systems Director [5%]; Facilities Manager [5%]; Facilities Director [5%] |
| 5 | Close project | 2009-09-08 → 2009-08-07 A (-32d) | 2009-09-14 → 2009-08-14 A (-31d) |  | 0% → 100% | -9d → none |  | resources Project Manager; Information Systems Director; Facilities Manager; Procurement Manager; Architect; General Contractor; Interior Designer → Project Manager; Information Systems Director; Facilities Manager; Procurement Manager; Architect; General Contractor; Interior Designer; Facilities Director |
| 25 | Designs complete | 2009-06-26 A | 2009-06-26 A |  | 0% → 100% | 53d → none |  | constraint none → start no earlier than 2009-06-26 |
| 26 | **Construction** | 2009-07-06 A | 2009-08-04 A |  | 0% → 100% | 14d → none |  |  |
| 27 | **Borlaug Building** | 2009-07-06 A | 2009-07-22 A |  | 0% → 100% | 9d → none |  |  |
| 28 | Build Lab B107 | 2009-07-16 A | 2009-07-22 A |  | 0% → 100% | 9d → none |  |  |
| 29 | Build Lab B108 | 2009-07-06 A | 2009-07-15 A |  | 0% → 100% | 14d → none |  |  |
| 30 | **Marquez Library** | 2009-07-06 A | 2009-07-22 A |  | 0% → 100% | 9d → none |  |  |
| 31 | Build Lab L315 | 2009-07-14 A | 2009-07-22 A |  | 0% → 100% | 9d → none |  |  |
| 32 | Build Lab L316 | 2009-07-06 A | 2009-07-13 A |  | 0% → 100% | 16d → none |  |  |
| 33 | **Salam Center** | 2009-07-06 A | 2009-08-04 A |  | 0% → 100% | 1d → none |  |  |
| 34 | Build Lab S324 | 2009-07-28 A | 2009-08-04 A |  | 0% → 100% | 1d → none |  |  |
| 35 | Build Lab S325 | 2009-07-16 A | 2009-07-24 A |  | 0% → 100% | 7d → none |  |  |
| 36 | Build Lab S326 | 2009-07-06 A | 2009-07-15 A |  | 0% → 100% | 14d → none |  |  |
| 37 | **Sen Building** | 2009-07-06 A | 2009-07-31 A |  | 0% → 100% | 2d → none |  |  |
| 38 | Build Lab E210 | 2009-07-27 A | 2009-07-31 A |  | 0% → 100% | 2d → none |  |  |
| 39 | Build Lab E211 | 2009-07-16 A | 2009-07-23 A |  | 0% → 100% | 8d → none |  |  |
| 40 | Build Lab E212 | 2009-07-06 A | 2009-07-15 A |  | 0% → 100% | 14d → none |  |  |
| 41 | Lab construction started | 2009-07-06 A | 2009-07-06 A |  | 0% → 100% | 49d → none |  |  |
| 42 | **Commissioning** | 2009-06-08 → 2009-06-26 A (+18d) | 2009-08-21 → 2009-08-07 A (-14d) | 53d → 28d | 0% → 100% | 1d → none |  |  |
| 43 | Test all labs | 2009-08-05 A | 2009-08-07 A |  | 0% → 100% | 11d → none |  |  |
| 44 | Produce as-built documents for all labs | 2009-08-05 → 2009-07-16 A (-20d) | 2009-08-21 → 2009-08-04 A (-17d) |  | 0% → 100% | 1d → none | 28, 29, 31, 32, 34, 35, 36, 38, 39, 40 → 28FF, 29FF, 31FF, 32FF, 34FF, 35FF, 36FF, 38FF, 39FF, 40FF |  |
| 45 | Produce operations and maintenance manuals | 2009-06-08 → 2009-06-26 A (+18d) | 2009-07-17 → 2009-08-06 A (+20d) | 25d → 27d | 0% → 100% | 25d → none |  | constraint none → start no earlier than 2009-06-26; resources Information Systems Director [25%]; Facilities Manager [25%] → Information Systems Director [27.8%]; Facilities Manager [25%]; Facilities Director [25%] |
| 46 | Operations manuals complete | 2009-07-17 → 2009-08-06 A (+20d) | 2009-07-17 → 2009-08-06 A (+20d) |  | 0% → 100% | 39d → none |  |  |
| 47 | Labs complete | 2009-08-07 A | 2009-08-07 A |  | 0% → 100% | 25d → none |  |  |
| 48 | Project complete | 2009-09-14 → 2009-08-14 A (-31d) | 2009-09-14 → 2009-08-14 A (-31d) |  | 0% → 100% | -9d → none |  |  |
